# Project Lifecycle

Schedule from MS Project, 2017-08-01 to 2017-10-16, costs in $, A marks actual dates.
Sam Huffman, PMP MCT MCITP

## Calendars

- My Calendar: Mon-Fri 08:00-12:00, 13:00-17:00; Sat-Sun off. Exceptions (off unless hours are given): 2017-09-04 (Labor Day 2017), 2017-10-09 (Columbus Day 2017).

## Resources

| Resource | Group | Unit | Rate |
| --- | --- | --- | --- |
| PM | Proj Team |  | 100 |
| Team | Proj Team |  | 75 |
| QA/QC | Proj Team |  | 100 |
| MGT TEAM | MGT Team |  | 150 |
| Printer Paper | Supplies | Reams | 16 |

## Schedule

| ID | WBS | Task | Type | Duration | Start | Finish | Predecessors | Complete | Baseline start | Baseline finish | Baseline duration | Total slack | Constraint | Resources | Work | Actual work | Cost | Baseline cost | Actual cost |
| --- | --- | --- | --- | --- | --- | --- | --- | --- | --- | --- | --- | --- | --- | --- | --- | --- | --- | --- | --- |
| 1 | 1 | **Define the project** |  | 9d | 2017-08-01 A | 2017-08-11 A |  | 100% | 2017-08-01 | 2017-08-11 | 9d |  |  |  | 176h | 176h | 21,248 | 21,248 | 21,248 |
| 2 | 1.1 | Create and negotiate definition documents |  | 3d | 2017-08-01 A | 2017-08-03 A |  | 100% | 2017-08-01 | 2017-08-03 | 3d |  |  | MGT TEAM; PM; QA/QC | 72h | 72h | 8,400 | 8,400 | 8,400 |
| 3 | 1.2 | Create and publish project announcement |  | 5d | 2017-08-04 A | 2017-08-10 A | 2 | 100% | 2017-08-04 | 2017-08-10 | 5d |  |  | MGT TEAM; PM; Printer Paper [3 Reams] | 80h | 80h | 10,048 | 10,048 | 10,048 |
| 4 | 1.3 | Assemble and organize project team |  | 2d | 2017-08-07 A | 2017-08-11 A | 3SS+1d | 100% | 2017-08-07 | 2017-08-11 | 2d |  |  | MGT TEAM; PM; QA/QC | 24h | 24h | 2,800 | 2,800 | 2,800 |
| 5 | 1.4 | Control Gate: Planning | milestone | 0d | 2017-08-11 A | 2017-08-11 A | 4 | 100% | 2017-08-11 | 2017-08-11 | 0d |  |  |  |  |  |  |  |  |
| 6 | 2 | **Plan the project** |  | 13d | 2017-08-14 A | 2017-08-30 A |  | 100% | 2017-08-14 | 2017-08-25 | 10d |  |  |  | 304h | 304h | 30,400 | 30,400 | 30,400 |
| 7 | 2.1 | Create tasks and organize per definition documents |  | 1d | 2017-08-14 A | 2017-08-14 A | 5 | 100% | 2017-08-14 | 2017-08-14 | 1d |  |  | PM; QA/QC; Team [300%] | 40h | 40h | 3,400 | 3,400 | 3,400 |
| 8 | 2.2 | Sequence tasks and estimate durations |  | 3d | 2017-08-15 A | 2017-08-17 A | 7 | 100% | 2017-08-15 | 2017-08-17 | 3d |  |  | Team [500%] | 120h | 120h | 9,000 | 9,000 | 9,000 |
| 9 | 2.3 | Identify resources and assign to tasks |  | 3d | 2017-08-18 A | 2017-08-29 A | 8 | 100% | 2017-08-18 | 2017-08-22 | 3d |  |  | MGT TEAM [200%]; PM; QA/QC | 96h | 96h | 12,000 | 12,000 | 12,000 |
| 10 | 2.4 | Level resources and get buy off from management |  | 3d | 2017-08-28 A | 2017-08-30 A | 9FF | 100% | 2017-08-23 | 2017-08-25 | 3d |  | start no earlier than 2017-08-25 | MGT TEAM; PM | 48h | 48h | 6,000 | 6,000 | 6,000 |
| 11 | 2.5 | Control Gate: Begin Work | milestone | 0d | 2017-08-30 A | 2017-08-30 A | 10 | 100% | 2017-08-25 | 2017-08-25 | 0d |  |  |  |  |  |  |  |  |
| 12 | 3 | **Conduct project work and reviews** |  | 26d | 2017-08-31 A | 2017-10-06 A |  | 100% | 2017-08-28 | 2017-09-21 | 18d |  |  |  | 944h | 944h | 71,400 | 47,400 | 71,400 |
| 13 | 3.1 | Conduct work cycle 1 |  | 15d | 2017-08-31 A | 2017-09-21 A | 11 | 100% | 2017-08-28 | 2017-09-06 | 7d |  |  | Team [500%] | 600h | 600h | 45,000 | 21,000 | 45,000 |
| 14 | 3.2 | Review for quality 1 |  | 1d | 2017-09-22 A | 2017-09-22 A | 13 | 100% | 2017-09-07 | 2017-09-07 | 1d |  |  | QA/QC | 8h | 8h | 800 | 800 | 800 |
| 15 | 3.3 | Conduct work cycle 2 |  | 1d | 2017-09-25 A | 2017-09-25 A | 14 | 100% | 2017-09-08 | 2017-09-08 | 1d |  |  | Team [500%] | 40h | 40h | 3,000 | 3,000 | 3,000 |
| 16 | 3.4 | Review for quality 2 |  | 1d | 2017-09-26 A | 2017-09-26 A | 15 | 100% | 2017-09-11 | 2017-09-11 | 1d |  |  | QA/QC | 8h | 8h | 800 | 800 | 800 |
| 17 | 3.5 | Conduct work cycle 3 |  | 7d | 2017-09-27 A | 2017-10-05 A | 16 | 100% | 2017-09-12 | 2017-09-20 | 7d |  |  | Team [500%] | 280h | 280h | 21,000 | 21,000 | 21,000 |
| 18 | 3.6 | Review for quality 3 |  | 1d | 2017-10-06 A | 2017-10-06 A | 17 | 100% | 2017-09-21 | 2017-09-21 | 1d |  |  | QA/QC | 8h | 8h | 800 | 800 | 800 |
| 19 | 3.7 | Control Gate: Close and Document | milestone | 0d | 2017-10-06 A | 2017-10-06 A | 18 | 100% | 2017-09-21 | 2017-09-21 | 0d |  |  |  |  |  |  |  |  |
| 20 | 4 | **Project close out and documentation** |  | 5d | 2017-10-10 | 2017-10-16 |  |  | 2017-09-22 | 2017-09-28 | 5d | 0d |  |  | 96h |  | 9,032 | 9,032 |  |
| 21 | 4.1 | Close project books |  | 1d | 2017-10-10 | 2017-10-10 | 19 |  | 2017-09-22 | 2017-09-22 | 1d | 0d |  | PM | 8h |  | 800 | 800 |  |
| 22 | 4.2 | Release resources to management |  | 1d | 2017-10-11 | 2017-10-11 | 21 |  | 2017-09-25 | 2017-09-25 | 1d | 0d |  | PM | 8h |  | 800 | 800 |  |
| 23 | 4.3 | Prepare final report |  | 1d | 2017-10-12 | 2017-10-12 | 22 |  | 2017-09-26 | 2017-09-26 | 1d | 0d |  | PM; Printer Paper [2 Reams] | 8h |  | 832 | 832 |  |
| 24 | 4.4 | Post Mortem meeting with management |  | 1d | 2017-10-13 | 2017-10-13 | 23 |  | 2017-09-27 | 2017-09-27 | 1d | 0d |  | MGT TEAM; PM; QA/QC | 24h |  | 2,800 | 2,800 |  |
| 25 | 4.5 | Post Mortem meeting with team. |  | 1d | 2017-10-16 | 2017-10-16 | 24 |  | 2017-09-28 | 2017-09-28 | 1d | 0d |  | Team [500%]; PM | 48h |  | 3,800 | 3,800 |  |
